# zaidi sedili

Schedule from MS Project, 2012-01-02 to 2012-11-22, costs in RM.

## Calendars

- Standard: Mon-Fri 08:00-12:00, 13:00-17:00; Sat-Sun off.

## Resources

| Resource | Rate |
| --- | --- |
| General Labour | 6.25 |
| Skill Worker | 12.5 |
| Concrete Leveller/Screeder | 8.75 |
| Drainlayer | 9.38 |
| Bricklayer | 9.38 |
| Carpenter and Joiner | 10 |
| Steel Bar Bender and Fixer | 10 |
| Plumber | 10 |
| Painter | 8.75 |
| Roofer | 8 |
| Ironworker | 8 |
| Pavior/Plasterer | 8 |
| Tile Fixer | 10.63 |
| Watchman | 7.5 |
| Lorry | 35 |
| Excavator | 57 |
| Excavator Operator | 10 |
| Dumper | 45 |
| Dumper Driver | 10 |
| Bulldozer | 35 |
| Bulldozer Driver | 10 |
| Compactor | 30 |
| Backhoe | 30 |
| Backhoe Driver | 10 |
| Pneumatic Roller | 20 |
| Roller Operator | 10 |
| Electrician | 12 |
| Bricks Sumps | 35 |
| Anti-termite | 20 |
| Site Investigation | 100 |
| Gasoline | 2.5 |
| Lubricant | 10 |
| Diesel | 1.8 |
| Formwork | 9 |
| Signboard | 6 |
| Site Office | 10000 |
| Electrical Tools | 50 |
| Box gutter | 49.4 |
| 100mm diam UPVC | 30.4 |
| Water tank 660 gallon | 1578 |
| Floor joist roof trusses | 1452 |
| 38mm thick framed | 146.1 |
| 1800 x 2100 x 38 mm door leaf | 2516 |
| 300 x 300 x 8.5mm non slipt heavy duty homogeneius tiles | 86.1 |
| plastering 16mm thick 1:6 | 9.9 |
| 200 x 200 x 7mm glazed walls tiles | 60 |
| WR 150mm dia UPVC pipe | 70.9 |
| ALLUMINIUM FOIL | 12 |
| Bitominius roof caping 580mm | 22.9 |
| Ceramic roofing tiles | 79.6 |
| Paint finishing coat | 7.2 |
| Half brickwall 1:6 | 39 |
| Half brickwall 1:3 | 39.7 |
| Mild steel roof trusses | 4.6 |
| 10mm rebars | 3 |
| 12mm rebars | 2.9 |
| 16mm rebars | 2.8 |
| 6mm glazing | 89.5 |
| Excavate | 6.5 |
| Concrete G15 | 194.5 |
| Concrete G 30 | 286.3 |
| Damp proof membrance | 12.9 |
| Water proofing | 3 |
| Ceiling installment | 42 |
| Ceiling linning | 70 |
| 150x150mm Precast concrete piles <3m | 115.6 |
| 200x200mm Precast concrete piles <3m | 62.5 |
| Driven piling machine | 100 |
| Cutting pile machine | 16.8 |
| Cold water system | 7000 |
| Storage water tank | 7000 |
| Timber | 5.9 |
| Plywood | 18.3 |
| Cabinet Type B 15 | 315 |
| Cabinet Type B 13 | 616 |
| cabinet Type S 18 | 840 |
| Cabinet Type G 8 | 350 |
| Cabinet Type KK 6 | 175 |
| Wardrobe Type BT 5 | 574 |
| Wardrobe Type KT 6 | 357 |
| Cabinet Type KK 2 | 560 |
| Cabinet Type RT 1 | 1050 |
| Cabinet Type BT 1 | 175 |
| Cabinet Type RM 1 | 357 |
| Furnishing Concrete Base Grade 30 | 154 |
| Furnishing Concrete Base REF A6 | 10.5 |
| Furnishing Concrete Based Class F1 | 4.38 |
| Furnishing concrete base 1:3 | 45.5 |
| sanitary basin | 245 |
| Sanitary water closet | 560 |
| Sanitary close couple wash down | 490 |
| Sanitary sink | 245 |
| Sanitary shower | 126 |
| Sanitary soup holder | 35 |
| Sanitary Semi recessed soup dish | 35 |
| Sanitary miror | 245 |
| Sanitary toilet roll holder | 35 |
| Sanitary towel rail | 35 |
| Sanitary tap and hand bidet | 35 |
| Sanitary hand bidet set complete | 35 |
| Sanitary water trough | 105 |
| Sanitary floor trap | 10.5 |
| Skirting 100mm high | 3.8 |
| Testing plumbing | 500 |
| Sanitary appliances | 1000 |
| Plain concrete Grade 7 | 140 |
| Stirrups | 3 |
| Coats Cold Bitumen | 7 |
| Ceramic Floor Tile | 38.5 |
| Wrot pressure treated Group B timber 200mm x 25mm | 10 |
| Wrot pressure treated Group B timber 300mm x 25mm | 15 |
| Wrot pressure treated Group B timber 75mm x 50mm Tie | 6.75 |
| Wrot pressure treated Group B timber 100mm x 75mm Wall Plate | 13.5 |
| Roofing concrete interlocking tiles Sloping | 25 |
| Roofing concrete interlocking tiles Valley tiles | 15 |
| Roofing concrete interlocking tiles Ridge tiles | 15 |
| Roofing concrete interlocking tiles Hip tiles | 15 |
| Roofing concrete interlocking tiles 3 way apex | 10 |
| half brick thick in cement mortar (1:3) | 30 |
| railing 1200x1100mm mild steel | 200 |
| Precast concrete 150x115mm Grade 30 | 10.35 |
| Frame 600x200x195mm Type GTA6a | 46.8 |
| Frame 75x17mm Group 'B' timber | 2.25 |
| Door 800x40mm Type P6 | 250 |
| Door 800x2100x38mm Type P10 | 300 |
| Panelled Door 900x2100x40mm Type P3 | 150 |
| Panelled Door 1500x2100x40 Type P1 | 600 |
| Ironmongery for window | 50 |
| Mild steel Sliding door 900x2100mm Type GP4 | 189 |
| Mild steel Sliding door 1500x2100mm Type GP1 | 315 |
| Mild steel Sliding door 1800x2100mm Type GP9 | 378 |
| Mild steel door frame 320 girth | 15 |
| Double door 1800x2100mm Type P9 | 567 |
| Mild steel window grille 600x600mm Type GTA14 | 36 |
| Mild steel window grille1200x600mm Type GTA15 | 72 |
| Mild steel window grille1800x1800mm Type GTA8a | 324 |
| Window hunger 600x560mm Type TA14 | 46.8 |
| Window hunger 1200x560mm Type TA15 | 46.8 |
| Window 1800x1800mm Type TA8a | 421.2 |
| Window 600x1200mm (side hung window)Type TA1a | 93.6 |
| Glazing compound | 60 |
| Glazing strip and silicon topping 0.1-0.5m2 | 60 |
| Glazing strip and silicon topping 0.5-1m2 | 60 |
| Precast concrete 115x115mm Grade 20 | 7.2 |
| Flush door Type P6 | 120 |
| Door 800x2100x40mm Type P10 | 150 |
| Door 900x2100x38mm Type P5 | 150 |
| Door 900x2100x40mm Type P4 | 150 |
| Door 600x2100x40mm Type P10a | 80 |
| Panelled door 900x2100x40mm | 200 |
| Ironmongery for door | 50 |
| Mild steel door frame 320mm girth | 152 |
| levelling tools | 3 |
| PATENTED' roof trusses | 25000 |
| UPVC box gutters and fitting | 20 |
| Prime and enamel paint - 150mm-300mm Girth | 2.1 |
| Prime and enamel paint - Over 300mm Girth | 7 |
| Homogenous Floor Tiles | 65 |
| Wiringman | 12 |

## Schedule

| ID | WBS | Task | Duration | Start | Finish | Predecessors | Baseline start | Baseline finish | Baseline duration | Total slack | Free slack | Resources | Work | Cost |
| --- | --- | --- | --- | --- | --- | --- | --- | --- | --- | --- | --- | --- | --- | --- |
| 1 | 1 | **RUMAH BANGLO KELAS D 2 TINGKAT** | 234d | 2012-01-02 | 2012-11-22 |  |  |  |  | 0d |  |  | 12816h | 529,889.64 |
| 2 | 1.1 | **PRELIMINARY WORK** | 18d | 2012-01-02 | 2012-01-25 |  | 2012-04-23 | 2012-11-22 | 154d | 0d |  |  | 376h | 23,959 |
| 3 | 1.1.1 | site investigation | 14d | 2012-01-02 | 2012-01-19 |  | 2012-04-23 | 2012-09-21 | 110d | 0d |  | Site Investigation | 112h | 11,200 |
| 4 | 1.1.2 | **Temporary work** | 4d | 2012-01-20 | 2012-01-25 |  | 2012-11-05 | 2012-11-22 | 14d | 0d |  |  | 264h | 12,759 |
| 5 | 1.1.2.1 | temporary existing road | 1d | 2012-01-20 | 2012-01-20 | 3 | 2012-11-05 | 2012-11-07 | 2.5d | 0d |  | General Labour [400%]; Compactor; Skill Worker | 48h | 540 |
| 6 | 1.1.2.2 | signbord work | 1d | 2012-01-20 | 2012-01-20 | 5SS | 2012-11-05 | 2012-11-09 | 5d | 0d |  | Signboard; General Labour | 8h | 56 |
| 7 | 1.1.2.3 | store building | 1d | 2012-01-20 | 2012-01-20 | 6SS | 2012-11-05 | 2012-11-07 | 3d | 0d |  | General Labour [300%]; Timber [600%]; Plywood [500%] | 24h | 276.9 |
| 8 | 1.1.2.4 | parking | 1d | 2012-01-20 | 2012-01-20 | 7SS | 2012-11-05 | 2012-11-06 | 2d | 0d |  | Compactor; General Labour [200%]; Skill Worker | 32h | 440 |
| 9 | 1.1.2.5 | house workers | 2d | 2012-01-20 | 2012-01-23 | 8SS | 2012-11-05 | 2012-11-13 | 7d | 0d |  | Timber [1500%]; Plywood [1200%]; General Labour [400%] | 64h | 708.1 |
| 10 | 1.1.2.6 | toilet, electrical and water supply | 3d | 2012-01-20 | 2012-01-24 | 9SS | 2012-11-05 | 2012-11-22 | 14d | 0d |  | General Labour [200%]; Electrician; Electrical Tools | 72h | 638 |
| 11 | 1.1.2.7 | cabin | 1d | 2012-01-25 | 2012-01-25 | 10 | 2012-11-05 | 2012-11-13 | 7d | 0d |  | Site Office; General Labour [200%] | 16h | 10,100 |
| 12 | 1.2 | **SITE WORK** | 20d | 2012-01-26 | 2012-02-22 |  | 2012-11-26 | 2013-02-04 | 51d | 0d |  |  | 648h | 12,902 |
| 13 | 1.2.1 | **Site Preparation** | 4d | 2012-01-26 | 2012-01-31 |  | 2012-11-26 | 2012-12-04 | 7d | 0d |  |  | 160h | 3,020 |
| 14 | 1.2.1.1 | site clearance | 2d | 2012-01-26 | 2012-01-27 | 11 | 2012-12-07 | 2012-12-11 | 3d | 0d |  | General Labour [200%]; Backhoe; Backhoe Driver; Lorry | 80h | 1,400 |
| 15 | 1.2.1.2 | stripping soil | 2d | 2012-01-30 | 2012-01-31 | 14 | 2012-12-17 | 2012-12-19 | 3d | 0d |  | Backhoe; Backhoe Driver; Dumper; Dumper Driver; General Labour | 80h | 1,620 |
| 16 | 1.2.2 | **Earthwork** | 16d | 2012-02-01 | 2012-02-22 |  | 2012-12-20 | 2013-01-30 | 30d | 0d |  |  | 488h | 9,882 |
| 17 | 1.2.2.1 | cut and fill | 5d | 2012-02-01 | 2012-02-07 | 15 | 2012-12-20 | 2012-12-24 | 3d | 0d |  | Excavator; Excavator Operator; General Labour [200%]; Lorry; Backhoe; Backhoe Driver | 280h | 6,180 |
| 18 | 1.2.2.2 | levelling | 2d | 2012-02-08 | 2012-02-09 | 17 |  |  |  | 0d |  | Skill Worker; General Labour [200%]; Compactor | 64h | 880 |
| 19 | 1.2.2.3 | grading | 2d | 2012-02-10 | 2012-02-13 | 18 | 2012-12-25 | 2012-12-27 | 3d | 0d |  | Skill Worker; General Labour | 32h | 300 |
| 20 | 1.2.2.4 | compacting | 5d | 2012-02-14 | 2012-02-20 | 19 | 2013-01-14 | 2013-01-17 | 4d | 0d |  | Compactor; General Labour | 80h | 1,450 |
| 21 | 1.2.2.5 | excavate the temporary earth drain | 2d | 2012-02-21 | 2012-02-22 | 20 | 2013-01-31 | 2013-02-01 | 2d | 0d |  | Excavator; Excavator Operator | 32h | 1,072 |
| 22 | 1.3 | **SUB-STRUCTURE** | 36d | 2012-02-23 | 2012-04-12 |  |  |  |  | 0d |  |  | 552h | 16,559.8 |
| 23 | 1.3.1 | **Piling Works** | 14d | 2012-02-23 | 2012-03-13 |  |  |  |  | 0d |  |  | 160h | 10,037.4 |
| 24 | 1.3.1.1 | **Driven Piles (Type 1)** | 13d | 2012-02-23 | 2012-03-12 |  |  |  |  | 0d |  |  | 104h | 7,259.4 |
| 25 | 1.3.1.1.1 | Driven Piles | 8d | 2012-02-23 | 2012-03-05 | 20, 21 |  |  |  | 0d |  | Driven piling machine; 200x200mm Precast concrete piles <3m [600%] | 64h | 6,775 |
| 26 | 1.3.1.1.2 | Cut Off surplus length | 1d | 2012-03-06 | 2012-03-06 | 25 |  |  |  | 1d | 0d | General Labour; Cutting pile machine | 16h | 184.4 |
| 27 | 1.3.1.1.3 | Load Testing (PDA) | 3d | 2012-03-08 | 2012-03-12 | 26FS+1d |  |  |  | 1d |  | Skill Worker | 24h | 300 |

| ID | WBS | Task | Duration | Start | Finish | Predecessors | Total slack | Free slack | Resources | Work | Cost |
| --- | --- | --- | --- | --- | --- | --- | --- | --- | --- | --- | --- |
| 28 | 1.3.1.2 | **Driven Piles (Type 2)** | 6d | 2012-03-06 | 2012-03-13 |  | 0d |  |  | 56h | 2,778 |
| 29 | 1.3.1.2.1 | Driven Piles | 2d | 2012-03-06 | 2012-03-07 | 25 | 0d |  | Driven piling machine; 150x150mm Precast concrete piles <3m [600%] | 16h | 2,293.6 |
| 30 | 1.3.1.2.2 | Cut Off surplus length | 1d | 2012-03-08 | 2012-03-08 | 29 | 0d |  | Cutting pile machine; General Labour | 16h | 184.4 |
| 31 | 1.3.1.2.3 | Load Testing (PDA) | 3d | 2012-03-09 | 2012-03-13 | 30 | 0d |  | Skill Worker | 24h | 300 |
| 32 | 1.3.2 | **Pile Cap** | 14d | 2012-03-14 | 2012-04-02 |  | 0d |  |  | 248h | 3,730.9 |
| 33 | 1.3.2.1 | Backfill & Platform Leveling ( Before laying Lean Concrete) | 2d | 2012-03-14 | 2012-03-15 | 27, 31 | 0d |  | General Labour [300%] | 48h | 300 |
| 34 | 1.3.2.2 | Anti- Terminte Chemical soil treatment | 2d | 2012-03-14 | 2012-03-15 | 33FF | 0d |  | Anti-termite | 16h | 320 |
| 35 | 1.3.2.3 | Lean Concrete | 2d | 2012-03-16 | 2012-03-19 | 34 | 0d |  | General Labour [200%]; Concrete G15 [400%] | 32h | 978 |
| 36 | 1.3.2.4 | Polythene Sheet damp Proof Membrance | 1d | 2012-03-20 | 2012-03-20 | 35 | 0d |  | Damp proof membrance; General Labour [200%] | 16h | 112.9 |
| 37 | 1.3.2.5 | Formwork | 1d | 2012-03-21 | 2012-03-21 | 36 | 0d |  | Formwork [2000%]; General Labour [200%] | 16h | 280 |
| 38 | 1.3.2.6 | Rebars | 3d | 2012-03-22 | 2012-03-26 | 37 | 0d |  | Formwork [10000%]; General Labour [200%] | 48h | 1,200 |
| 39 | 1.3.2.7 | Concrete | 1d | 2012-03-27 | 2012-03-27 | 38 | 0d |  | Formwork [1000%]; General Labour [400%] | 32h | 290 |
| 40 | 1.3.2.8 | Curing | 3d | 2012-03-28 | 2012-03-30 | 39 | 0d |  | General Labour | 24h | 150 |
| 41 | 1.3.2.9 | Dismantle Formwork | 1d | 2012-04-02 | 2012-04-02 | 40 | 0d |  | General Labour [200%] | 16h | 100 |
| 42 | 1.3.3 | **Column Stump** | 8d | 2012-04-03 | 2012-04-12 |  | 34d |  |  | 144h | 2,791.5 |
| 43 | 1.3.3.1 | Formwork | 1d | 2012-04-03 | 2012-04-03 | 41 | 34d | 0d | Formwork [2000%]; General Labour [200%] | 16h | 280 |
| 44 | 1.3.3.2 | Rebars | 2d | 2012-04-04 | 2012-04-05 | 43 | 34d | 0d | 16mm rebars [10000%]; General Labour [400%] | 64h | 680 |
| 45 | 1.3.3.3 | Concrete | 1d | 2012-04-06 | 2012-04-06 | 44 | 34d | 0d | Concrete G 30 [500%]; General Labour [200%] | 16h | 1,531.5 |
| 46 | 1.3.3.4 | Curing | 3d | 2012-04-09 | 2012-04-11 | 45 | 34d | 0d | General Labour | 24h | 150 |
| 47 | 1.3.3.5 | Dismantle Formwork | 1d | 2012-04-12 | 2012-04-12 | 46 | 34d |  | General Labour [300%] | 24h | 150 |
| 48 | 1.4 | **SUPERSTRUCTURE** | 143d | 2012-04-03 | 2012-10-18 |  | 0d |  |  | 4032h | 201,866.8 |
| 49 | 1.4.1 | **Ground Floor Beams** | 19d | 2012-04-03 | 2012-04-27 |  | 0d |  |  | 288h | 10,848.4 |
| 50 | 1.4.1.1 | Anti- Terminte | 1d | 2012-04-03 | 2012-04-03 | 41 | 0d |  | Anti-termite | 8h | 160 |
| 51 | 1.4.1.2 | Concrete Topping | 3d | 2012-04-04 | 2012-04-06 | 50 | 0d |  | Concrete G15 [500%]; General Labour [200%] | 48h | 1,272.5 |
| 52 | 1.4.1.3 | Damp Proof Membrance | 1d | 2012-04-09 | 2012-04-09 | 51 | 0d |  | Damp proof membrance |  | 12.9 |
| 53 | 1.4.1.4 | Formwork | 2d | 2012-04-10 | 2012-04-11 | 52 | 0d |  | Formwork [500%]; General Labour [200%]; Coats Cold Bitumen [42800%] | 32h | 3,241 |
| 54 | 1.4.1.5 | Rebars | 5d | 2012-04-12 | 2012-04-18 | 53 | 0d |  | 16mm rebars [10000%]; General Labour [300%]; Stirrups [83400%] | 120h | 3,532 |
| 55 | 1.4.1.6 | Concrete | 3d | 2012-04-19 | 2012-04-23 | 54 | 0d |  | General Labour [200%]; Plain concrete Grade 7 [1500%] | 48h | 2,400 |
| 56 | 1.4.1.7 | Curing | 3d | 2012-04-24 | 2012-04-26 | 55 | 0d |  | General Labour | 24h | 150 |
| 57 | 1.4.1.8 | Dismantle Formwork | 1d | 2012-04-27 | 2012-04-27 | 56 | 0d |  | Carpenter and Joiner | 8h | 80 |

| ID | WBS | Task | Duration | Start | Finish | Predecessors | Total slack | Resources | Work | Cost |
| --- | --- | --- | --- | --- | --- | --- | --- | --- | --- | --- |
| 58 | 1.4.2 | **Ground Floor Slabs** | 42d | 2012-04-03 | 2012-05-30 |  | 0d |  | 296h | 8,181.9 |
| 59 | 1.4.2.1 | Anti-Termite | 1d | 2012-04-03 | 2012-04-03 | 50SS | 18d | Anti-termite | 8h | 160 |
| 60 | 1.4.2.2 | Concrete Topping | 3d | 2012-04-30 | 2012-05-02 | 57, 59 | 0d | Concrete G15 [500%]; General Labour [200%] | 48h | 1,272.5 |
| 61 | 1.4.2.3 | Service Pipes | 2d | 2012-05-03 | 2012-05-04 | 60 | 0d | Plumber; 100mm diam UPVC [1000%] | 16h | 464 |
| 62 | 1.4.2.4 | Damp Proof Membrane | 2d | 2012-05-07 | 2012-05-08 | 61 | 0d | Damp proof membrance |  | 12.9 |
| 63 | 1.4.2.5 | Formwork | 2d | 2012-05-09 | 2012-05-10 | 62 | 0d | Formwork [1500%]; General Labour [200%]; Coats Cold Bitumen [42800%] | 32h | 3,331 |
| 64 | 1.4.2.6 | Rebars | 5d | 2012-05-11 | 2012-05-17 | 63 | 0d | 16mm rebars [10000%]; General Labour [200%] | 80h | 780 |
| 65 | 1.4.2.7 | Concrete | 5d | 2012-05-18 | 2012-05-24 | 64 | 0d | Concrete G 30 [500%]; General Labour [200%] | 80h | 1,931.5 |
| 66 | 1.4.2.8 | Curing | 3d | 2012-05-25 | 2012-05-29 | 65 | 0d | General Labour | 24h | 150 |
| 67 | 1.4.2.9 | Dismantile Formwork | 1d | 2012-05-30 | 2012-05-30 | 66 | 0d | Carpenter and Joiner | 8h | 80 |
| 68 | 1.4.3 | **Ground Floor Columns** | 18d | 2012-05-31 | 2012-06-25 |  | 0d |  | 264h | 8,348 |
| 69 | 1.4.3.1 | Formwork | 2d | 2012-05-31 | 2012-06-01 | 47, 67 | 0d | Formwork [1500%]; General Labour [200%]; Coats Cold Bitumen [42800%] | 32h | 3,331 |
| 70 | 1.4.3.2 | Rebars | 5d | 2012-06-04 | 2012-06-08 | 69 | 0d | 16mm rebars [10000%]; General Labour [200%] | 80h | 780 |
| 71 | 1.4.3.3 | Service Pipe | 3d | 2012-06-11 | 2012-06-13 | 70 | 0d | Plumber; 100mm diam UPVC [1000%] | 24h | 544 |
| 72 | 1.4.3.4 | Concrete | 4d | 2012-06-14 | 2012-06-19 | 71 | 0d | Concrete G 30 [1000%]; General Labour [300%] | 96h | 3,463 |
| 73 | 1.4.3.5 | Curing | 3d | 2012-06-20 | 2012-06-22 | 72 | 0d | General Labour | 24h | 150 |
| 74 | 1.4.3.6 | Dismantle Formwork | 1d | 2012-06-25 | 2012-06-25 | 73 | 0d | Carpenter and Joiner | 8h | 80 |
| 75 | 1.4.4 | **First Floor Beams** | 21d | 2012-06-26 | 2012-07-24 |  | 0d |  | 352h | 11,812.4 |
| 76 | 1.4.4.1 | Concrete Topping | 3d | 2012-06-26 | 2012-06-28 | 74 | 0d | Concrete G15 [500%]; General Labour [200%] | 48h | 1,272.5 |
| 77 | 1.4.4.2 | Damp Proof Membrance | 2d | 2012-06-29 | 2012-07-02 | 76 | 0d | Damp proof membrance |  | 12.9 |
| 78 | 1.4.4.3 | Formwork | 2d | 2012-07-03 | 2012-07-04 | 77 | 0d | Formwork [2000%]; General Labour [200%]; Coats Cold Bitumen [42800%] | 32h | 3,376 |
| 79 | 1.4.4.4 | Rebars | 5d | 2012-07-05 | 2012-07-11 | 78 | 0d | 16mm rebars [2000%]; General Labour [300%]; Stirrups [83400%] | 120h | 3,308 |
| 80 | 1.4.4.5 | Concrete | 5d | 2012-07-12 | 2012-07-18 | 79 | 0d | Concrete G 30 [1000%]; General Labour [300%] | 120h | 3,613 |
| 81 | 1.4.4.6 | Curing | 3d | 2012-07-19 | 2012-07-23 | 80 | 0d | General Labour | 24h | 150 |
| 82 | 1.4.4.7 | Dismantle Formwork | 1d | 2012-07-24 | 2012-07-24 | 81 | 0d | Carpenter and Joiner | 8h | 80 |

| ID | WBS | Task | Duration | Start | Finish | Predecessors | Total slack | Free slack | Resources | Work | Cost |
| --- | --- | --- | --- | --- | --- | --- | --- | --- | --- | --- | --- |
| 83 | 1.4.5 | **First Floor Slabs** | 24d | 2012-07-25 | 2012-08-27 |  | 0d |  |  | 352h | 3,544.1 |
| 84 | 1.4.5.1 | Formwork | 2d | 2012-07-25 | 2012-07-26 | 82 | 0d |  |  |  |  |
| 85 | 1.4.5.2 | Concrete Topping | 2d | 2012-07-27 | 2012-07-30 | 84 | 0d |  | Concrete G15; General Labour [200%] | 32h | 394.5 |
| 86 | 1.4.5.3 | Service Pipes | 3d | 2012-07-31 | 2012-08-02 | 85 | 0d |  | Plumber [200%]; 100mm diam UPVC [300%] | 48h | 571.2 |
| 87 | 1.4.5.4 | Damp Proof Membrane | 2d | 2012-08-03 | 2012-08-06 | 86 | 0d |  | Damp proof membrance [200%]; General Labour | 16h | 125.8 |
| 88 | 1.4.5.5 | Rebars | 5d | 2012-08-07 | 2012-08-13 | 87 | 0d |  | 16mm rebars [10000%]; General Labour [300%] | 120h | 1,030 |
| 89 | 1.4.5.6 | Concrete | 6d | 2012-08-14 | 2012-08-21 | 88 | 0d |  | Concrete G 30 [200%]; General Labour [200%] | 96h | 1,172.6 |
| 90 | 1.4.5.7 | Curing | 3d | 2012-08-22 | 2012-08-24 | 89 | 7d | 0d | General Labour | 24h | 150 |
| 91 | 1.4.5.8 | Dismantile Formwork | 1d | 2012-08-27 | 2012-08-27 | 90 | 7d | 0d | General Labour [200%] | 16h | 100 |
| 92 | 1.4.6 | **First Floor Columns** | 16d | 2012-08-23 | 2012-09-13 |  | 0d |  |  | 328h | 5,905.6 |
| 93 | 1.4.6.1 | Formwork | 2d | 2012-08-23 | 2012-08-24 | 89FS+1d | 0d |  | Formwork [500%]; General Labour [200%]; Carpenter and Joiner; Coats Cold Bitumen [42800%] | 48h | 3,401 |
| 94 | 1.4.6.2 | Rebars | 5d | 2012-08-27 | 2012-08-31 | 93 | 0d |  | 16mm rebars [6500%]; General Labour [300%] | 120h | 932 |
| 95 | 1.4.6.3 | Concrete | 5d | 2012-09-03 | 2012-09-07 | 94 | 0d |  | Concrete G 30 [200%]; General Labour [300%] | 120h | 1,322.6 |
| 96 | 1.4.6.4 | Curing | 3d | 2012-09-10 | 2012-09-12 | 95 | 0d |  | General Labour | 24h | 150 |
| 97 | 1.4.6.5 | Dismantle Formwork | 1d | 2012-09-13 | 2012-09-13 | 96 | 0d |  | General Labour [200%] | 16h | 100 |
| 98 | 1.4.7 | **Roof Beam** | 12d | 2012-09-14 | 2012-10-01 |  | 0d |  |  | 248h | 9,757.4 |
| 99 | 1.4.7.1 | Formwork | 1d | 2012-09-14 | 2012-09-17 | 95FS+1d, 97 | 0d |  | Formwork [2000%]; General Labour [400%]; Carpenter and Joiner [200%] | 48h | 540 |
| 100 | 1.4.7.2 | Rebars | 4d | 2012-09-18 | 2012-09-21 | 99 | 0d |  | General Labour [400%]; 10mm rebars [93800%] | 128h | 3,614 |
| 101 | 1.4.7.3 | Concrete | 2d | 2012-09-24 | 2012-09-25 | 100 | 0d |  | Concrete G 30 [1800%]; General Labour [200%] | 32h | 5,353.4 |
| 102 | 1.4.7.4 | Curing | 3d | 2012-09-26 | 2012-09-28 | 101 | 0d |  | General Labour | 24h | 150 |
| 103 | 1.4.7.5 | Dismantle formwork | 1d | 2012-10-01 | 2012-10-01 | 102 | 0d |  | General Labour [200%] | 16h | 100 |
| 104 | 1.4.8 | **Roof Slab** | 13d | 2012-10-02 | 2012-10-18 |  | 0d |  |  | 296h | 9,472 |
| 105 | 1.4.8.1 | Formwork | 2d | 2012-10-02 | 2012-10-03 | 103 | 0d |  | Formwork [800%]; General Labour [300%]; Carpenter and Joiner | 64h | 532 |
| 106 | 1.4.8.2 | Rebars | 3d | 2012-10-04 | 2012-10-08 | 105 | 0d |  | General Labour [400%]; 10mm rebars [56800%] | 96h | 2,304 |
| 107 | 1.4.8.3 | Concrete | 3d | 2012-10-09 | 2012-10-11 | 106 | 0d |  | Concrete G 30 [2000%]; General Labour [300%] | 72h | 6,176 |
| 108 | 1.4.8.4 | Curing | 3d | 2012-10-12 | 2012-10-16 | 107 | 0d |  | General Labour | 24h | 150 |
| 109 | 1.4.8.5 | Dismantle formwork | 1d | 2012-10-17 | 2012-10-17 | 108 | 0d |  | General Labour [300%] | 24h | 150 |
| 110 | 1.4.8.6 | Water proofing and Asphalt work | 1d | 2012-10-18 | 2012-10-18 | 109 | 0d |  | Water proofing [2000%]; General Labour [200%] | 16h | 160 |

| ID | WBS | Task | Duration | Start | Finish | Predecessors | Total slack | Free slack | Resources | Work | Cost |
| --- | --- | --- | --- | --- | --- | --- | --- | --- | --- | --- | --- |
| 111 | 1.4.9 | **Staircase** | 13d | 2012-08-28 | 2012-09-13 |  | 7d |  |  | 272h | 7,434.2 |
| 112 | 1.4.9.1 | Formwork | 2d | 2012-08-28 | 2012-08-29 | 91 | 7d | 0d | Formwork [800%]; General Labour [300%]; Carpenter and Joiner | 64h | 532 |
| 113 | 1.4.9.2 | Rebars | 5d | 2012-08-30 | 2012-09-05 | 112 | 50d | 0d | 16mm rebars [10800%]; General Labour [300%]; 12mm rebars [83200%]; 10mm rebars [800%] | 120h | 3,489.2 |
| 114 | 1.4.9.3 | Concrete | 2d | 2012-09-06 | 2012-09-07 | 113 | 50d | 0d | Concrete G 30 [1000%]; General Labour [300%] | 48h | 3,163 |
| 115 | 1.4.9.4 | Curing | 3d | 2012-09-10 | 2012-09-12 | 114 | 50d | 0d | General Labour | 24h | 150 |
| 116 | 1.4.9.5 | Dismantle formwork | 1d | 2012-09-13 | 2012-09-13 | 115 | 50d |  | General Labour [200%] | 16h | 100 |
| 117 | 1.4.10 | **Ground Floor Wall** | 10d | 2012-08-28 | 2012-09-10 |  | 7d |  |  | 504h | 30,721.2 |
| 118 | 1.4.10.1 | **external wall** | 10d | 2012-08-28 | 2012-09-10 |  | 7d |  |  | 272h | 18,140.6 |
| 119 | 1.4.10.1.1 | levelling | 2d | 2012-08-28 | 2012-08-29 | 112SS | 7d | 0d | General Labour [200%]; levelling tools [500%] | 32h | 215 |
| 120 | 1.4.10.1.2 | brickworks | 5d | 2012-09-04 | 2012-09-10 | 119FS+3d | 18.5d | 0d | Bricklayer [300%]; General Labour [300%]; Half brickwall 1:6 [7000%]; half brick thick in cement mortar (1:3) [44400%] | 240h | 17,925.6 |
| 121 | 1.4.10.2 | **internal wall** | 10d | 2012-08-28 | 2012-09-10 |  | 7d |  |  | 232h | 12,580.6 |
| 122 | 1.4.10.2.1 | levelling | 2d | 2012-08-28 | 2012-08-29 | 119SS | 7d | 0d | General Labour [200%]; levelling tools [500%] | 32h | 215 |
| 123 | 1.4.10.2.2 | brickworks | 5d | 2012-09-04 | 2012-09-10 | 122FS+3d | 7d | 0d | Bricklayer [300%]; General Labour [300%]; half brick thick in cement mortar (1:3) [35800%] | 200h | 12,365.6 |
| 124 | 1.4.11 | **First Floor Wall** | 9d | 2012-09-11 | 2012-09-21 |  | 7d |  |  | 528h | 30,871.2 |
| 125 | 1.4.11.1 | **external wall** | 9d | 2012-09-11 | 2012-09-21 |  | 7d |  |  | 256h | 18,040.6 |
| 126 | 1.4.11.1.1 | levelling | 1d | 2012-09-11 | 2012-09-11 | 123 | 7d | 0d | General Labour [200%]; levelling tools [500%] | 16h | 115 |
| 127 | 1.4.11.1.2 | brickworks | 5d | 2012-09-17 | 2012-09-21 | 126FS+3d | 7d | 0d | Bricklayer [300%]; Half brickwall 1:6 [7000%]; General Labour [300%]; half brick thick in cement mortar (1:3) [44400%] | 240h | 17,925.6 |
| 128 | 1.4.11.2 | **internal wall** | 8d | 2012-09-11 | 2012-09-20 |  | 11d |  |  | 272h | 12,830.6 |
| 129 | 1.4.11.2.1 | levelling | 2d | 2012-09-11 | 2012-09-12 | 126SS | 11d | 0d | General Labour [200%]; levelling tools [500%] | 32h | 215 |
| 130 | 1.4.11.2.2 | brickworks | 5d | 2012-09-14 | 2012-09-20 | 129SS+3d | 11d | 0d | Bricklayer [300%]; General Labour [300%]; half brick thick in cement mortar (1:3) [35800%] | 240h | 12,615.6 |
| 131 | 1.4.12 | **Window** | 12d | 2012-09-11 | 2012-09-26 |  | 9.5d |  |  | 192h | 39,006.4 |
| 132 | 1.4.12.1 | **ground floor** | 3d | 2012-09-11 | 2012-09-13 |  | 18.5d |  |  | 96h | 19,503.2 |
| 133 | 1.4.12.1.1 | frame | 2d | 2012-09-11 | 2012-09-12 | 120 | 18.5d | 0d | General Labour [200%]; Mild steel window grille 600x600mm Type GTA14 [200%]; Mild steel window grille1200x600mm Type GTA15 [800%]; Skill Worker [200%]; Window hunger 600x560mm Type TA14 [600%]; Window hunger 1200x560mm Type TA15 [1000%]; Window 1800x1800mm Type TA8a [1600%]; Window 600x1200mm (side hung window)Type TA1a [200%]; Ironmongery for window [8800%] | 64h | 13,323.2 |
| 134 | 1.4.12.1.2 | glass | 1d | 2012-09-13 | 2012-09-13 | 133 | 18.5d | 0d | General Labour [200%]; Glazing compound [3800%]; Glazing strip and silicon topping 0.1-0.5m2 [2600%]; Glazing strip and silicon topping 0.5-1m2 [3400%]; Skill Worker [200%] | 32h | 6,180 |

| ID | WBS | Task | Duration | Start | Finish | Predecessors | Total slack | Free slack | Resources | Work | Cost |
| --- | --- | --- | --- | --- | --- | --- | --- | --- | --- | --- | --- |
| 135 | 1.4.12.2 | **1st floor** | 3d | 2012-09-24 | 2012-09-26 |  | 7d |  |  | 96h | 19,503.2 |
| 136 | 1.4.12.2.1 | frame | 2d | 2012-09-24 | 2012-09-25 | 127 | 7d | 0d | General Labour [200%]; Mild steel window grille 600x600mm Type GTA14 [200%]; Mild steel window grille1200x600mm Type GTA15 [800%]; Skill Worker [200%]; Window hunger 600x560mm Type TA14 [600%]; Window hunger 1200x560mm Type TA15 [1000%]; Window 1800x1800mm Type TA8a [1600%]; Window 600x1200mm (side hung window)Type TA1a [200%]; Ironmongery for window [8800%] | 64h | 13,323.2 |
| 137 | 1.4.12.2.2 | glass | 1d | 2012-09-26 | 2012-09-26 | 136 | 7d | 0d | General Labour [200%]; Glazing compound [3800%]; Glazing strip and silicon topping 0.1-0.5m2 [2600%]; Glazing strip and silicon topping 0.5-1m2 [3400%]; Skill Worker [200%] | 32h | 6,180 |
| 138 | 1.4.13 | **Door** | 11d | 2012-09-11 | 2012-09-25 |  | 10.5d |  |  | 112h | 25,964 |
| 139 | 1.4.13.1 | **ground floor** | 2d | 2012-09-11 | 2012-09-12 |  | 19.5d |  |  | 56h | 12,982 |
| 140 | 1.4.13.1.1 | frame installation | 1d | 2012-09-11 | 2012-09-11 | 133SS | 19.5d | 0d | General Labour [200%]; Mild steel door frame 320 girth [6200%] | 16h | 1,030 |
| 141 | 1.4.13.1.2 | door installation | 1d | 2012-09-12 | 2012-09-12 | 140 | 19.5d | 1d | Door 800x2100x38mm Type P10 [400%]; Door 900x2100x38mm Type P5 [400%]; Door 900x2100x40mm Type P4 [1000%]; Door 600x2100x40mm Type P10a [200%]; Panelled Door 900x2100x40mm Type P3 [200%]; Ironmongery for door [15800%]; Ironworker [300%]; General Labour [200%] | 40h | 11,952 |
| 142 | 1.4.13.2 | **1st floor** | 2d | 2012-09-24 | 2012-09-25 |  | 8d |  |  | 56h | 12,982 |
| 143 | 1.4.13.2.1 | frame installation | 1d | 2012-09-24 | 2012-09-24 | 136SS | 8d | 0d | General Labour [200%]; Mild steel door frame 320 girth [6200%] | 16h | 1,030 |
| 144 | 1.4.13.2.2 | door installation | 1d | 2012-09-25 | 2012-09-25 | 143 | 8d | 1d | General Labour [200%]; Door 800x2100x38mm Type P10 [400%]; Door 900x2100x38mm Type P5 [400%]; Door 900x2100x40mm Type P4 [1000%]; Door 600x2100x40mm Type P10a [200%]; Ironmongery for door [15800%]; Ironworker [300%]; Panelled Door 900x2100x40mm Type P3 [200%] | 40h | 11,952 |
| 145 | 1.5 | **INTERNAL WORK** | 46d | 2012-09-11 | 2012-11-13 |  | 7d |  |  | 1656h | 180,410.64 |
| 146 | 1.5.1 | **Roof** | 5d | 2012-10-19 | 2012-10-25 |  | 0d |  |  | 136h | 56,845.6 |
| 147 | 1.5.1.1 | Steel Truss Fabricated Installation | 1d | 2012-10-19 | 2012-10-19 | 110 | 0d |  | PATENTED' roof trusses [200%]; Roofer; General Labour [400%] | 40h | 50,264 |
| 148 | 1.5.1.2 | Boarding and Flooring | 2d | 2012-10-22 | 2012-10-23 | 147 | 0d |  | General Labour [200%]; Wrot pressure treated Group B timber 200mm x 25mm [2400%]; Wrot pressure treated Group B timber 300mm x 25mm [23800%]; Wrot pressure treated Group B timber 75mm x 50mm Tie [1200%]; Wrot pressure treated Group B timber 100mm x 75mm Wall Plate [9400%]; Carpenter and Joiner [200%] | 64h | 5,680 |
| 149 | 1.5.1.3 | Painting Woodwork | 2d | 2012-10-24 | 2012-10-25 | 148 | 0d |  | Painter [200%]; Prime and enamel paint - 150mm-300mm Girth [3600%]; Prime and enamel paint - Over 300mm Girth [7800%] | 32h | 901.6 |
| 150 | 1.5.2 | **M&E** | 11d | 2012-09-11 | 2012-09-25 |  | 17d |  |  | 112h | 1,894 |
| 151 | 1.5.2.1 | Conduit | 6d | 2012-09-11 | 2012-09-18 | 119SS, 122SS, 126SS, 129SS | 17d | 0d | Electrician; Electrical Tools [400%] | 48h | 776 |
| 152 | 1.5.2.2 | Wiring | 3d | 2012-09-19 | 2012-09-21 | 151 | 17d | 0d | Electrical Tools [500%]; Wiringman [200%] | 48h | 826 |
| 153 | 1.5.2.3 | Fitting | 2d | 2012-09-24 | 2012-09-25 | 152 | 17d | 0d | Electrical Tools [200%]; Electrician | 16h | 292 |
| 154 | 1.5.3 | **Sanitary Installation** | 14d | 2012-09-26 | 2012-10-15 |  | 17d |  |  | 224h | 11,291 |
| 155 | 1.5.3.1 | Sanitary Fitting | 14d | 2012-09-26 | 2012-10-15 | 153 | 17d | 0d | sanitary basin [400%]; Sanitary close couple wash down [400%]; Sanitary floor trap [1000%]; Sanitary hand bidet set complete [600%]; Sanitary miror [600%]; Sanitary Semi recessed soup dish [200%]; Sanitary shower [600%]; Sanitary sink [400%]; Sanitary soup holder [400%]; Sanitary tap and hand bidet [200%]; Sanitary toilet roll holder [600%]; Sanitary towel rail [600%]; Sanitary water closet [200%]; Sanitary water trough [200%]; Skill Worker [200%] | 224h | 11,291 |
| 156 | 1.5.4 | **Plumbing Installation** | 10d | 2012-10-16 | 2012-10-29 |  | 17d |  |  | 144h | 47,000 |
| 157 | 1.5.4.1 | Cold Water Systems | 2d | 2012-10-16 | 2012-10-17 | 155 | 17d | 0d | Cold water system; Skill Worker | 16h | 7,200 |
| 158 | 1.5.4.2 | Storage Water Tank | 2d | 2012-10-18 | 2012-10-19 | 157SS+2d | 17d | 0d | Storage water tank; General Labour [200%] | 32h | 7,200 |
| 159 | 1.5.4.3 | Sanitary Pipe Installation | 2d | 2012-10-22 | 2012-10-23 | 158SS+2d | 17d | 0d | Sanitary appliances; Skill Worker | 32h | 16,200 |
| 160 | 1.5.4.4 | Testing Pipework | 4d | 2012-10-24 | 2012-10-29 | 157, 158, 159 | 17d |  | Testing plumbing; Skill Worker | 64h | 16,400 |

| ID | WBS | Task | Duration | Start | Finish | Predecessors | Total slack | Free slack | Resources | Work | Cost |
| --- | --- | --- | --- | --- | --- | --- | --- | --- | --- | --- | --- |
| 161 | 1.5.5 | **Finishes** | 32d | 2012-09-14 | 2012-10-29 |  | 7d |  |  | 888h | 43,273 |
| 162 | 1.5.5.1 | **Wall** | 24d | 2012-09-14 | 2012-10-17 |  | 15d |  |  | 352h | 19,395 |
| 163 | 1.5.5.1.1 | **ground floor** | 15d | 2012-09-14 | 2012-10-04 |  | 18.5d |  |  | 176h | 12,451.2 |
| 164 | 1.5.5.1.1.1 | Plastering | 7d | 2012-09-14 | 2012-09-24 | 123, 134, 141 | 18.5d | 0d | Pavior/Plasterer [200%]; Half brickwall 1:6 [17600%] | 112h | 7,760 |
| 165 | 1.5.5.1.1.2 | Tile Installation | 5d | 2012-09-25 | 2012-10-01 | 164 | 24d | 0d | 200 x 200 x 7mm glazed walls tiles [4600%]; Tile Fixer | 40h | 3,185.2 |
| 166 | 1.5.5.1.1.3 | **painting** | 3d | 2012-10-02 | 2012-10-04 |  | 24d |  |  | 24h | 1,506 |
| 167 | 1.5.5.1.1.3.1 | Under coat | 1d | 2012-10-02 | 2012-10-02 | 165 | 24d | 0d | Painter; Paint finishing coat [9000%] | 8h | 718 |
| 168 | 1.5.5.1.1.3.2 | Finishing Coat | 2d | 2012-10-03 | 2012-10-04 | 167 | 24d |  | Paint finishing coat [9000%]; Painter | 16h | 788 |
| 169 | 1.5.5.1.2 | **first floor** | 15d | 2012-09-27 | 2012-10-17 |  | 7d |  |  | 176h | 6,943.8 |
| 170 | 1.5.5.1.2.1 | Plastering | 7d | 2012-09-27 | 2012-10-05 | 130, 137, 144 | 7d | 0d | Pavior/Plasterer [200%]; Half brickwall 1:6 [400%] | 112h | 1,052 |
| 171 | 1.5.5.1.2.2 | Tile Installation | 5d | 2012-10-08 | 2012-10-12 | 170 | 15d | 0d | Tile Fixer; 300 x 300 x 8.5mm non slipt heavy duty homogeneius tiles [4600%] | 40h | 4,385.8 |
| 172 | 1.5.5.1.2.3 | **painting** | 3d | 2012-10-15 | 2012-10-17 |  | 15d |  |  | 24h | 1,506 |
| 173 | 1.5.5.1.2.3.1 | Under coat | 1d | 2012-10-15 | 2012-10-15 | 171 | 15d | 0d | Painter; Paint finishing coat [9000%] | 8h | 718 |
| 174 | 1.5.5.1.2.3.2 | Finishing Coat | 2d | 2012-10-16 | 2012-10-17 | 173 | 15d | 8d | Paint finishing coat [9000%]; Painter | 16h | 788 |
| 175 | 1.5.5.2 | **Ceiling** | 16d | 2012-09-25 | 2012-10-16 |  | 9.5d |  |  | 352h | 8,376 |
| 176 | 1.5.5.2.1 | **ground floor** | 7d | 2012-09-25 | 2012-10-03 |  | 18.5d |  |  | 296h | 4,124 |
| 177 | 1.5.5.2.1.1 | Plastering | 3d | 2012-09-25 | 2012-09-27 | 164 | 18.5d | 0d | Pavior/Plasterer; plastering 16mm thick 1:6 [30000%] | 264h | 2,568 |
| 178 | 1.5.5.2.1.2 | **painting** | 3d | 2012-09-28 | 2012-10-02 |  | 18.5d |  |  | 24h | 1,506 |
| 179 | 1.5.5.2.1.2.1 | Under Coat | 1d | 2012-09-28 | 2012-09-28 | 177 | 18.5d | 0d | Paint finishing coat [9000%]; Painter | 8h | 718 |
| 180 | 1.5.5.2.1.2.2 | Finishing Coat | 2d | 2012-10-01 | 2012-10-02 | 179 | 18.5d | 0d | Paint finishing coat [9000%]; Painter | 16h | 788 |
| 181 | 1.5.5.2.1.3 | Cleaning | 1d | 2012-10-03 | 2012-10-03 | 180 | 18.5d | 0d | General Labour | 8h | 50 |
| 182 | 1.5.5.2.2 | **first floor** | 7d | 2012-10-08 | 2012-10-16 |  | 7d |  |  | 56h | 4,252 |
| 183 | 1.5.5.2.2.1 | Lining | 2d | 2012-10-08 | 2012-10-09 | 170 | 7d | 0d | Ceiling linning [3000%]; General Labour | 16h | 2,200 |
| 184 | 1.5.5.2.2.2 | Ceiling Board | 1d | 2012-10-10 | 2012-10-10 | 183 | 7d | 0d | Ceiling installment [3000%]; Skill Worker | 8h | 1,360 |

| ID | WBS | Task | Duration | Start | Finish | Predecessors | Total slack | Free slack | Resources | Work | Cost |
| --- | --- | --- | --- | --- | --- | --- | --- | --- | --- | --- | --- |
| 185 | 1.5.5.2.2.3 | **painting** | 3d | 2012-10-11 | 2012-10-15 |  | 7d |  |  | 24h | 642 |
| 186 | 1.5.5.2.2.3.1 | Under Coat | 1d | 2012-10-11 | 2012-10-11 | 184 | 7d | 0d | Painter; Paint finishing coat [3000%] | 8h | 286 |
| 187 | 1.5.5.2.2.3.2 | Finishing Coat | 2d | 2012-10-12 | 2012-10-15 | 186 | 7d | 0d | Paint finishing coat [3000%]; Painter | 16h | 356 |
| 188 | 1.5.5.2.2.4 | Cleaning | 1d | 2012-10-16 | 2012-10-16 | 187 | 7d | 0d | General Labour | 8h | 50 |
| 189 | 1.5.5.3 | **Floor** | 18d | 2012-10-04 | 2012-10-29 |  | 7d |  |  | 184h | 15,502 |
| 190 | 1.5.5.3.1 | **ground floor** | 6.5d | 2012-10-04 | 2012-10-12 |  | 18.5d |  |  | 96h | 8,822.8 |
| 191 | 1.5.5.3.1.1 | Rendering | 1d | 2012-10-04 | 2012-10-04 | 181 | 18.5d | 0d | Half brickwall 1:3 [3000%]; General Labour [200%] | 16h | 1,291 |
| 192 | 1.5.5.3.1.2 | Water Proofing | 1d | 2012-10-04 | 2012-10-04 | 191FF | 18.5d | 0d | Water proofing [600%]; Skill Worker [200%] | 16h | 218 |
| 193 | 1.5.5.3.1.3 | Tile Installation | 2.5d | 2012-10-05 | 2012-10-09 | 192 | 18.5d | 0d | Tile Fixer [200%]; 300 x 300 x 8.5mm non slipt heavy duty homogeneius tiles [3600%]; Ceramic Floor Tile [3400%]; Homogenous Floor Tiles [3000%] | 40h | 6,783.8 |
| 194 | 1.5.5.3.1.4 | Skirting | 2d | 2012-10-09 | 2012-10-11 | 193 | 18.5d | 0d | General Labour; Skirting 100mm high [10000%] | 16h | 480 |
| 195 | 1.5.5.3.1.5 | Cleaning | 1d | 2012-10-11 | 2012-10-12 | 194 | 18.5d | 11.5d | General Labour | 8h | 50 |
| 196 | 1.5.5.3.2 | **first floor** | 9d | 2012-10-17 | 2012-10-29 |  | 7d |  |  | 88h | 6,679.2 |
| 197 | 1.5.5.3.2.1 | Rendering | 1d | 2012-10-17 | 2012-10-17 | 188 | 7d | 0d | General Labour; Half brickwall 1:3 [3000%] | 8h | 1,241 |
| 198 | 1.5.5.3.2.2 | Water Proofing | 1d | 2012-10-17 | 2012-10-17 | 197FF | 7d | 0d | Water proofing [600%]; General Labour [200%] | 16h | 118 |
| 199 | 1.5.5.3.2.3 | Tile Installation | 5d | 2012-10-18 | 2012-10-24 | 198 | 7d | 0d | 300 x 300 x 8.5mm non slipt heavy duty homogeneius tiles [2600%]; Tile Fixer; Homogenous Floor Tiles [3400%] | 40h | 4,873.8 |
| 200 | 1.5.5.3.2.4 | Skirting | 2d | 2012-10-25 | 2012-10-26 | 199 | 7d | 0d | General Labour; Skirting 100mm high [7800%] | 16h | 396.4 |
| 201 | 1.5.5.3.2.5 | Cleaning | 1d | 2012-10-29 | 2012-10-29 | 200 | 7d | 0d | General Labour | 8h | 50 |
| 202 | 1.5.6 | **Cabinet Installation** | 9d | 2012-10-30 | 2012-11-09 |  | 7d |  |  | 112h | 17,531.52 |
| 203 | 1.5.6.1 | Cabinet Fitting | 5d | 2012-10-30 | 2012-11-05 | 168, 181, 188, 195, 201, 174 | 7d | 0d | Cabinet Type BT 1 [600%]; Cabinet Type B 13 [400%]; Cabinet Type B 15 [400%]; Cabinet Type G 8 [400%]; Cabinet Type KK 2 [200%]; Cabinet Type KK 6 [200%]; Cabinet Type RM 1 [200%]; Cabinet Type RT 1 [400%]; cabinet Type S 18 [400%]; Skill Worker [200%] | 80h | 16,918 |
| 204 | 1.5.6.2 | Furnishing | 4d | 2012-11-06 | 2012-11-09 | 203 | 7d | 0d | Furnishing Concrete Base Grade 30; Furnishing Concrete Base REF A6 [400%]; Furnishing Concrete Based Class F1 [400%]; Skill Worker | 32h | 613.52 |
| 205 | 1.5.7 | **Wardrobe Installation** | 11d | 2012-10-30 | 2012-11-13 |  | 7d |  |  | 40h | 2,575.52 |
| 206 | 1.5.7.1 | Wardrobe Fitting | 3d | 2012-10-30 | 2012-11-01 | 203SS | 13d | 6d | Wardrobe Type BT 5 [200%]; Wardrobe Type KT 6 [200%]; Skill Worker | 24h | 2,162 |
| 207 | 1.5.7.2 | Furnishing | 2d | 2012-11-12 | 2012-11-13 | 206, 204FF+2d | 7d |  | Furnishing Concrete Base Grade 30; Furnishing Concrete Base REF A6 [400%]; Furnishing Concrete Based Class F1 [400%]; Skill Worker | 16h | 413.52 |
| 208 | 1.6 | **EXTERNAL WORK** | 52d | 2012-09-12 | 2012-11-22 |  | 0d |  |  | 5552h | 94,191.4 |
| 209 | 1.6.1 | **Roof** | 8d | 2012-10-26 | 2012-11-06 |  | 0d |  |  | 280h | 33,849.6 |
| 210 | 1.6.1.1 | Roof Tiles installation | 3d | 2012-10-26 | 2012-10-30 | 149 | 0d |  | Roofer [200%]; General Labour [400%]; Roofing concrete interlocking tiles Sloping [70200%]; Roofing concrete interlocking tiles Valley tiles [5200%]; Roofing concrete interlocking tiles Ridge tiles [2800%]; Roofing concrete interlocking tiles Hip tiles [9400%]; Roofing concrete interlocking tiles 3 way apex [400%]; ALLUMINIUM FOIL [70200%] | 144h | 29,608 |
| 211 | 1.6.1.2 | Gutterwork | 2d | 2012-10-31 | 2012-11-01 | 210 | 0d |  | General Labour [400%]; UPVC box gutters and fitting [7400%] | 64h | 1,880 |
| 212 | 1.6.1.3 | Pipework | 3d | 2012-11-02 | 2012-11-06 | 211 | 0d |  | Plumber [300%]; 100mm diam UPVC [5400%] | 72h | 2,361.6 |

| ID | WBS | Task | Duration | Start | Finish | Predecessors | Total slack | Free slack | Resources | Work | Cost |
| --- | --- | --- | --- | --- | --- | --- | --- | --- | --- | --- | --- |
| 213 | 1.6.2 | **Drainage** | 4d | 2012-11-07 | 2012-11-12 |  | 0d |  |  | 96h | 2,422.2 |
| 214 | 1.6.2.1 | Drains | 3d | 2012-11-07 | 2012-11-09 | 212 | 0d |  | Excavator; Excavator Operator | 48h | 1,608 |
| 215 | 1.6.2.2 | Sump | 1d | 2012-11-12 | 2012-11-12 | 214 | 0d |  | General Labour; Concrete G15 [200%]; Bricklayer [1000%] | 48h | 814.2 |
| 216 | 1.6.3 | **Sewerage** | 4d | 2012-11-13 | 2012-11-16 |  | 0d |  |  | 48h | 1,072.6 |
| 217 | 1.6.3.1 | Precast Concrete Manhole | 2d | 2012-11-13 | 2012-11-14 | 215 | 0d |  | Skill Worker [200%]; Concrete G 30 [200%] | 32h | 972.6 |
| 218 | 1.6.3.2 | Manhole Cover Installation | 2d | 2012-11-15 | 2012-11-16 | 217 | 0d |  | General Labour | 16h | 100 |
| 219 | 1.6.4 | **Water Reticulation System** | 4d | 2012-11-19 | 2012-11-22 |  | 0d |  |  | 32h | 442 |
| 220 | 1.6.4.1 | Pipe Laying | 3d | 2012-11-19 | 2012-11-21 | 218 | 0d |  | Plumber; 100mm diam UPVC [500%] | 24h | 392 |
| 221 | 1.6.4.2 | Valves Installation | 1d | 2012-11-22 | 2012-11-22 | 220, 160 | 0d |  | General Labour | 8h | 50 |
| 222 | 1.6.5 | **M&E** | 2d | 2012-09-26 | 2012-09-27 |  | 40d |  |  | 16h | 192 |
| 223 | 1.6.5.1 | TNB Cable Laying | 2d | 2012-09-26 | 2012-09-27 | 153 | 40d |  | Electrician | 16h | 192 |
| 224 | 1.6.6 | **Finishes** | 26d | 2012-09-12 | 2012-10-17 |  | 26d |  |  | 5080h | 56,213 |
| 225 | 1.6.6.1 | **Wall** | 19d | 2012-09-12 | 2012-10-08 |  | 26d |  |  | 4288h | 42,321 |
| 226 | 1.6.6.1.1 | **ground floor** | 11d | 2012-09-12 | 2012-09-26 |  | 26d |  |  | 2984h | 29,492 |
| 227 | 1.6.6.1.1.1 | Plastering | 7d | 2012-09-12 | 2012-09-20 | 123FS+1d | 26d | 0d | Pavior/Plasterer [200%]; plastering 16mm thick 1:6 [5000%] | 2912h | 28,616 |
| 228 | 1.6.6.1.1.2 | Water Proofing | 1d | 2012-09-20 | 2012-09-20 | 227FF | 26d | 0d | General Labour [200%]; Water proofing [3000%] | 16h | 190 |
| 229 | 1.6.6.1.1.3 | **painting** | 3d | 2012-09-21 | 2012-09-25 |  | 26d |  |  | 48h | 636 |
| 230 | 1.6.6.1.1.3.1 | Under Coat | 1d | 2012-09-21 | 2012-09-21 | 228 | 26d | 0d | Painter [400%] | 32h | 280 |
| 231 | 1.6.6.1.1.3.2 | Finishing Coat | 2d | 2012-09-24 | 2012-09-25 | 230 | 26d | 0d | Painter; Paint finishing coat [3000%] | 16h | 356 |
| 232 | 1.6.6.1.1.4 | Cleaning | 1d | 2012-09-26 | 2012-09-26 | 231 | 26d | 0d | General Labour | 8h | 50 |
| 233 | 1.6.6.1.2 | **first floor** | 11d | 2012-09-24 | 2012-10-08 |  | 30d |  |  | 1304h | 12,829 |
| 234 | 1.6.6.1.2.1 | Plastering | 7d | 2012-09-24 | 2012-10-02 | 130FS+1d | 30d | 0d | Pavior/Plasterer [200%]; plastering 16mm thick 1:6 [2000%] | 1232h | 11,984 |
| 235 | 1.6.6.1.2.2 | Water Proofing | 1d | 2012-10-02 | 2012-10-02 | 234FF | 30d | 0d | General Labour; Water proofing [2500%] | 8h | 125 |
| 236 | 1.6.6.1.2.3 | **painting** | 3d | 2012-10-03 | 2012-10-05 |  | 30d |  |  | 56h | 670 |
| 237 | 1.6.6.1.2.3.1 | Under Coat | 1d | 2012-10-03 | 2012-10-03 | 235 | 30d | 0d | Painter [300%] | 24h | 210 |
| 238 | 1.6.6.1.2.3.2 | Finishing Coat | 2d | 2012-10-04 | 2012-10-05 | 237 | 30d | 0d | Painter [200%]; Paint finishing coat [2500%] | 32h | 460 |
| 239 | 1.6.6.1.2.4 | Cleaning | 1d | 2012-10-08 | 2012-10-08 | 238 | 30d | 0d | General Labour | 8h | 50 |

| ID | WBS | Task | Type | Duration | Start | Finish | Predecessors | Total slack | Free slack | Resources | Work | Cost |
| --- | --- | --- | --- | --- | --- | --- | --- | --- | --- | --- | --- | --- |
| 240 | 1.6.6.2 | **Ceiling** |  | 11d | 2012-09-27 | 2012-10-11 |  | 26d |  |  | 712h | 10,152 |
| 241 | 1.6.6.2.1 | **ground floor** |  | 6d | 2012-09-27 | 2012-10-04 |  | 26d |  |  | 664h | 6,464 |
| 242 | 1.6.6.2.1.1 | Plastering |  | 3d | 2012-09-27 | 2012-10-01 | 232 | 26d | 0d | Pavior/Plasterer [200%]; plastering 16mm thick 1:6 [2500%] | 648h | 6,324 |
| 243 | 1.6.6.2.1.2 | **painting** |  | 3d | 2012-10-02 | 2012-10-04 |  | 26d |  |  | 16h | 140 |
| 244 | 1.6.6.2.1.2.1 | Under Coat |  | 1d | 2012-10-02 | 2012-10-02 | 242 | 26d | 0d | Painter [200%] | 16h | 140 |
| 245 | 1.6.6.2.1.2.2 | Finishing Coat |  | 2d | 2012-10-03 | 2012-10-04 | 244 | 26d | 0d |  |  |  |
| 246 | 1.6.6.2.2 | **first floor** |  | 3d | 2012-10-09 | 2012-10-11 |  | 30d |  |  | 48h | 3,688 |
| 247 | 1.6.6.2.2.1 | Lining |  | 2d | 2012-10-09 | 2012-10-10 | 170FS+1d, 239 | 30d | 0d | Ceiling linning [3400%]; General Labour [200%] | 32h | 2,580 |
| 248 | 1.6.6.2.2.2 | Ceiling Board |  | 1d | 2012-10-11 | 2012-10-11 | 247 | 30d |  | Ceiling installment [2400%]; General Labour [200%] | 16h | 1,108 |
| 249 | 1.6.6.3 | **Floor** |  | 9d | 2012-10-05 | 2012-10-17 |  | 26d |  |  | 80h | 3,740 |
| 250 | 1.6.6.3.1 | **ground Floor** |  | 9d | 2012-10-05 | 2012-10-17 |  | 26d |  |  | 80h | 3,740 |
| 251 | 1.6.6.3.1.1 | Rendering |  | 1d | 2012-10-05 | 2012-10-05 | 191SS, 245 | 26d | 0d | General Labour; Half brickwall 1:3 [3000%] | 8h | 1,241 |
| 252 | 1.6.6.3.1.2 | Water Proofing |  | 1d | 2012-10-05 | 2012-10-05 | 251FF | 26d | 0d | Water proofing [500%]; General Labour | 8h | 65 |
| 253 | 1.6.6.3.1.3 | Tiling |  | 5d | 2012-10-08 | 2012-10-12 | 252 | 26d | 0d | Tile Fixer; 300 x 300 x 8.5mm non slipt heavy duty homogeneius tiles [2000%] | 40h | 2,147.2 |
| 254 | 1.6.6.3.1.4 | Skirting |  | 2d | 2012-10-15 | 2012-10-16 | 253 | 26d | 0d | General Labour; Skirting 100mm high [3600%] | 16h | 236.8 |
| 255 | 1.6.6.3.1.5 | Cleaning |  | 1d | 2012-10-17 | 2012-10-17 | 254 | 26d |  | General Labour | 8h | 50 |
| 256 | 2 | End | milestone | 0d | 2012-11-22 | 2012-11-22 | 116, 248, 255, 207, 223, 221 | 0d |  |  |  |  |
